# 燕山立交

Schedule from MS Project, 2002-11-15 to 2003-07-30, status date 2002-07-23.
444

## Calendars

- 日历 (jns): Mon-Fri 08:00-12:00, 13:00-17:00; Sat-Sun off. Exceptions (off unless hours are given): 2002-10-04 to 2002-12-29 08:00-12:00, 13:00-17:00, 2003-01-01 to 2003-01-26 08:00-12:00, 13:00-17:00, 2003-02-01 to 2003-02-23 08:00-12:00, 13:00-17:00, 2003-03-01 to 2003-03-30 08:00-12:00, 13:00-17:00, 2003-04-05 to 2003-04-30 08:00-12:00, 13:00-17:00, 2003-05-03 to 2003-06-29 08:00-12:00, 13:00-17:00, 2003-07-01 to 2003-07-27 08:00-12:00, 13:00-17:00.

## Schedule

| ID | Task | Type | Duration | Start | Finish | Predecessors | Baseline start | Baseline finish | Baseline duration | Total slack | Free slack | Constraint |
| --- | --- | --- | --- | --- | --- | --- | --- | --- | --- | --- | --- | --- |
| 1 | 开始 | milestone | 0d | 2002-11-15 | 2002-11-15 |  | 2002-11-15 | 2002-11-15 | 0d? | 0d |  | start no earlier than 2002-11-15 |
| 2 | R10\L9联 |  | 50d | 2002-11-15 | 2003-01-03 | 1 | 2002-11-15 | 2003-01-03 | 50d | 0d |  |  |
| 3 | R12\L11联 |  | 50d | 2002-11-15 | 2003-01-03 | 1 | 2002-11-15 | 2003-01-03 | 50d | 0d |  |  |
| 4 | R11\L10\R4联 |  | 50d | 2002-12-25 | 2003-02-12 | 3FS-10d, 2FS-10d, 16FS-11d | 2002-12-25 | 2003-02-12 | 50d | 0d |  |  |
| 5 | R9\L8联 |  | 50d | 2003-02-03 | 2003-03-24 | 4FS-10d | 2003-02-03 | 2003-03-24 | 50d | 48d | 5d |  |
| 6 | R5\L4联 |  | 70d | 2003-02-03 | 2003-04-13 | 4FS-10d | 2003-02-03 | 2003-04-13 | 70d | 0d |  |  |
| 7 | R8\L7联 |  | 50d | 2003-05-13 | 2003-07-01 | 5, 8FS-11d | 2003-05-13 | 2003-07-01 | 50d | 0d |  |  |
| 8 | R6\L5联 |  | 50d | 2003-04-04 | 2003-05-23 | 6FS-10d | 2003-04-04 | 2003-05-23 | 50d | 0d |  |  |
| 9 | R7\L6联 |  | 40d | 2003-06-21 | 2003-07-30 | 7FS-11d | 2003-06-21 | 2003-07-30 | 40d | 0d |  |  |
| 10 | H1联 |  | 50d | 2002-12-25 | 2003-02-12 | 1FS+40d | 2002-12-25 | 2003-02-12 | 50d | 3d | 0d |  |
| 11 | H2联 |  | 50d | 2003-02-03 | 2003-03-24 | 10FS-10d | 2003-02-03 | 2003-03-24 | 50d | 3d | 0d |  |
| 12 | H3联 |  | 45d | 2003-03-15 | 2003-04-28 | 11FS-10d | 2003-03-15 | 2003-04-28 | 45d | 3d | 0d |  |
| 13 | H4联 |  | 45d | 2003-04-19 | 2003-06-02 | 12FS-10d | 2003-04-19 | 2003-06-02 | 45d | 3d | 0d |  |
| 14 | H6联 |  | 45d | 2003-05-24 | 2003-07-07 | 13FS-10d | 2003-05-24 | 2003-07-07 | 45d | 3d | 0d |  |
| 15 | H5联 |  | 30d | 2003-06-28 | 2003-07-27 | 14FS-10d | 2003-06-28 | 2003-07-27 | 30d | 3d |  |  |
| 16 | E7联 |  | 45d | 2002-11-15 | 2002-12-29 | 1 | 2002-11-15 | 2002-12-29 | 45d | 3d | 0d |  |
| 17 | E6联 |  | 60d | 2002-12-20 | 2003-02-17 | 16FS-10d | 2002-12-20 | 2003-02-17 | 60d | 3d | 0d |  |
| 18 | E5联 |  | 45d | 2003-02-08 | 2003-03-24 | 17FS-10d | 2003-02-08 | 2003-03-24 | 45d | 3d | 0d |  |
| 19 | E4联 |  | 45d | 2003-03-15 | 2003-04-28 | 18FS-10d | 2003-03-15 | 2003-04-28 | 45d | 3d | 0d |  |
| 20 | E1联 |  | 45d | 2003-04-19 | 2003-06-02 | 19FS-10d | 2003-04-19 | 2003-06-02 | 45d | 3d | 0d |  |
| 21 | E2联 |  | 45d | 2003-05-24 | 2003-07-07 | 20FS-10d, 6 | 2003-05-24 | 2003-07-07 | 45d | 3d | 0d |  |
| 22 | E3联 |  | 30d | 2003-06-28 | 2003-07-27 | 21FS-10d, 10 | 2003-06-28 | 2003-07-27 | 30d | 3d |  |  |
| 23 | B1联 |  | 30d | 2003-03-25 | 2003-04-23 | 5 | 2003-03-25 | 2003-04-23 | 30d | 15d | 0d |  |
| 24 | B2联 |  | 30d | 2003-04-14 | 2003-05-13 | 23FS-10d | 2003-04-14 | 2003-05-13 | 30d | 15d | 0d |  |
| 25 | B3联 |  | 30d | 2003-05-04 | 2003-06-02 | 24FS-10d | 2003-05-04 | 2003-06-02 | 30d | 15d | 0d |  |
| 26 | B4联 |  | 30d | 2003-05-24 | 2003-06-22 | 25FS-10d | 2003-05-24 | 2003-06-22 | 30d | 15d | 0d |  |
| 27 | B5联 |  | 30d | 2003-06-13 | 2003-07-12 | 26FS-10d | 2003-06-13 | 2003-07-12 | 30d | 15d |  |  |
| 28 | F8联 |  | 60d | 2002-11-15 | 2003-01-13 | 1 | 2002-11-15 | 2003-01-13 | 60d | 25d | 0d |  |
| 29 | F9联 |  | 60d | 2003-01-04 | 2003-03-04 | 28FS-10d | 2003-01-04 | 2003-03-04 | 60d | 40d | 0d |  |
| 30 | F10联 |  | 45d | 2003-02-23 | 2003-04-08 | 29FS-10d | 2003-02-23 | 2003-04-08 | 45d | 40d | 0d |  |
| 31 | F11联 |  | 45d | 2003-03-30 | 2003-05-13 | 30FS-10d, 5 | 2003-03-30 | 2003-05-13 | 45d | 40d | 0d |  |
| 32 | F12联 |  | 45d | 2003-05-04 | 2003-06-17 | 31FS-10d | 2003-05-04 | 2003-06-17 | 45d | 40d |  |  |
| 33 | G4联 |  | 45d | 2002-12-31 | 2003-02-13 | 1FS+46d | 2002-12-31 | 2003-02-13 | 45d | 4d | 0d |  |
| 34 | G5联 |  | 45d | 2003-02-04 | 2003-03-20 | 33FS-10d, 28 | 2003-02-04 | 2003-03-20 | 45d | 4d | 0d |  |
| 35 | G6联 |  | 45d | 2003-03-11 | 2003-04-24 | 34FS-10d | 2003-03-11 | 2003-04-24 | 45d | 4d | 0d |  |
| 36 | A1联 |  | 30d | 2003-04-25 | 2003-05-24 | 35 | 2003-04-25 | 2003-05-24 | 30d | 4d | 0d |  |
| 37 | A2联 |  | 30d | 2003-05-15 | 2003-06-13 | 36FS-10d | 2003-05-15 | 2003-06-13 | 30d | 4d | 0d |  |
| 38 | A3联 |  | 30d | 2003-06-04 | 2003-07-03 | 37FS-10d | 2003-06-04 | 2003-07-03 | 30d | 4d | 0d |  |
| 39 | A4联 |  | 30d | 2003-06-24 | 2003-07-23 | 38FS-10d | 2003-06-24 | 2003-07-23 | 30d | 4d |  |  |
| 40 | 结束 | milestone | 0d | 2003-07-30 | 2003-07-30 | 9, 15, 39, 32, 22, 27 | 2003-07-30 | 2003-07-30 | 0d? | 0d |  |  |
